# Top Off Project Schedule Working Draft Master v11-10

Schedule from MS Project, 2004-10-04 to 2007-04-23, A marks actual dates.
LBL

## Calendars

- Standard: Mon-Fri 08:00-12:00, 13:00-17:00; Sat-Sun off. Exceptions (off unless hours are given): 2005-12-26 to 2005-12-30.

## Resources

| Resource |
| --- |
| Stover |
| Shuman |
| Gath |
| Nishimura |
| Kwiatkowski |
| Byrne |
| Steier |
| Robin |
| Barry |
| Sannibale |
| Timossi |
| Chin |
| Scarvie |
| Mechanical Engineering |
| Ottens |
| Fahmie |
| Mueller |
| Donahue |
| Duarte |
| Wan |
| Jacobson |
| Williams |
| EM |
| Steele |
| EI |
| Urashka |
| EC |

## Schedule

| ID | WBS | Task | Type | Duration | Start | Finish | Predecessors | Complete | Remaining | Baseline start | Baseline finish | Baseline duration | Total slack | Free slack | Constraint | Resources | Work | Actual work |
| --- | --- | --- | --- | --- | --- | --- | --- | --- | --- | --- | --- | --- | --- | --- | --- | --- | --- | --- |
| 1 | 1 | **Top Off Project** |  | 661d? | 2004-10-04 A | 2007-04-23 |  | 28% | 473.51d? | 2004-10-04 | 2004-10-04 | 1d | 0d |  |  |  | 71336h | 9176.4h |
| 3 | 1.1 | Project Management |  | 26mo | 2004-10-04 A | 2006-10-06 |  | 50% | 13mo | 2004-10-04 | 2004-10-04 | 1d | 141d |  |  |  |  |  |
| 4 | 1.2 | Receive Additional FY05 Funding | milestone | 0d | 2005-03-01 A | 2005-03-01 A |  | 100% |  |  |  |  |  |  | start no earlier than 2005-03-01 |  |  |  |
| 5 | 1.3 | Receive FY06 Funding | milestone | 0d | 2005-10-03 | 2005-10-03 |  |  |  |  |  |  | 260d | 0d | start no earlier than 2005-10-03 |  |  |  |
| 6 | 1.4 | Installation Shutdown | milestone | 0d | 2006-09-04 | 2006-09-04 |  |  |  |  |  |  | 108d | 0d | start no earlier than 2006-09-04 |  |  |  |
| 7 | 1.5 | Approval of Delayed Scope | milestone | 0d | 2006-10-02 | 2006-10-02 |  |  |  |  |  |  | 0d |  | start no earlier than 2006-10-02 |  |  |  |
| 9 | 1.6 | **Top Off Documentation** |  | 80d | 2004-10-04 A | 2005-01-21 A |  | 100% |  | 2004-10-04 | 2004-10-04 | 1d |  |  |  |  |  |  |
| 10 | 1.6.1 | User Requirements | milestone | 0d | 2004-10-04 A | 2004-10-04 A |  | 100% |  | 2004-10-04 | 2004-10-04 | 1d |  |  |  |  |  |  |
| 11 | 1.6.2 | Specification |  | 16w | 2004-10-04 A | 2005-01-21 A |  | 100% |  | 2004-10-04 | 2004-10-04 | 1d |  |  |  |  |  |  |
| 12 | 1.6.3 | CDR |  | 12w | 2004-10-04 A | 2004-12-24 A |  | 100% |  | 2004-10-04 | 2004-10-04 | 1d |  |  |  |  |  |  |
| 13 | 1.6.4 | Top Off Documentation Complete | milestone | 0d | 2005-01-21 A | 2005-01-21 A | 10, 11, 12 | 100% |  |  |  |  |  |  |  |  |  |  |
| 15 | 1.7 | **Linac (Unapproved Scope)** |  | 100d | 2006-10-02 | 2007-02-16 |  |  |  | 2004-10-04 | 2004-10-04 | 1d | 46d |  |  |  |  |  |
| 16 | 1.7.1 | EDI |  | 8w | 2006-10-02 | 2006-11-24 | 7 |  |  | 2004-10-04 | 2004-10-04 | 1d | 106d | 60d |  |  |  |  |
| 17 | 1.7.2 | **Diagnostics** |  | 100d | 2006-10-02 | 2007-02-16 | 7 |  |  |  |  |  | 46d |  |  |  |  |  |
| 18 | 1.7.2.1 | **ICT Electronics** |  | 60d | 2006-10-02 | 2006-12-22 | 5 |  |  |  |  |  | 86d |  |  |  |  |  |
| 19 | 1.7.2.1.1 | Procurement |  | 12w | 2006-10-02 | 2006-12-22 |  |  |  |  |  |  | 86d | 40d |  |  |  |  |
| 20 | 1.7.2.2 | **BIM 1 (Wall Current Monitor)** |  | 100d | 2006-10-02 | 2007-02-16 | 5 |  |  |  |  |  | 46d |  |  |  |  |  |
| 21 | 1.7.2.2.1 | EDI |  | 8w | 2006-10-02 | 2006-11-24 |  |  |  |  |  |  | 46d | 0d |  |  |  |  |
| 22 | 1.7.2.2.2 | Component Procurement |  | 6w | 2006-11-27 | 2007-01-05 | 21 |  |  |  |  |  | 46d | 0d |  |  |  |  |
| 23 | 1.7.2.2.3 | Fabrication |  | 2w | 2007-01-08 | 2007-01-19 | 22 |  |  |  |  |  | 46d | 0d |  |  |  |  |
| 24 | 1.7.2.2.4 | Test |  | 4w | 2007-01-22 | 2007-02-16 | 23 |  |  |  |  |  | 46d | 0d |  |  |  |  |
| 25 | 1.7.3 | Linac Complete | milestone | 0d | 2007-02-16 | 2007-02-16 | 16, 19, 24 |  |  |  |  |  | 46d |  |  |  |  |  |
| 27 | 1.8 | **Booster** |  | 606d | 2004-11-22 A | 2007-03-26 |  | 40% | 363.17d | 2004-10-04 | 2004-10-04 | 1d | 20d |  |  |  | 10052h | 7800.4h |
| 28 | 1.8.1 | **Power Supplies** |  | 363.25d | 2005-04-22 A | 2006-09-21 |  | 29% | 259.5d | 2004-10-04 | 2004-10-04 | 1d | 152.75d |  |  |  | 4572h | 4516h |
| 29 | 1.8.1.1 | Write Specifications for Bend & Quads |  | 46.38ed | 2005-04-22 A | 2005-06-08 A |  | 100% |  | 2004-10-04 | 2004-10-04 | 1d |  |  | finish no earlier than 2005-07-01 | Fahmie; Timossi; Sannibale; Steier | 4452h | 4452h |
| 30 | 1.8.1.2 | Design Review/ReWrites if Needed |  | 5d | 2005-07-06 A | 2005-07-12 A |  | 100% |  |  |  |  |  |  | start no earlier than 2005-07-06 |  |  |  |
| 31 | 1.8.1.3 | Procurement Process/Order Bend & Quads |  | 6w | 2005-12-12 A | 2006-01-27 | 30, 403 | 10% | 5.4w |  |  |  | 181d | 0d |  |  |  |  |
| 32 | 1.8.1.4 | Bend & Quad PS Commercial Fab |  | 7mo | 2006-01-30 | 2006-08-11 | 31 |  |  |  |  |  | 181d | 0d | start no earlier than 2005-09-01 |  |  |  |
| 33 | 1.8.1.5 | Write Specifications for B1-B4 PS's |  | 2w | 2005-12-12 A | 2005-12-23 | 29, 403 | 80% | 0.4w |  |  |  | 174d | 0d | start no earlier than 2005-09-01 | Fahmie | 80h | 64h |
| 34 | 1.8.1.6 | Review of Specifications B1-B4 |  | 2d | 2006-01-02 | 2006-01-03 | 33 |  |  |  |  |  | 174d | 0d | start no earlier than 2005-09-15 |  |  |  |
| 35 | 1.8.1.7 | Procurement Process/Order B1-B4 PS's |  | 3w | 2006-01-04 | 2006-01-24 | 403, 34 |  |  |  |  |  | 174d | 0d |  |  |  |  |
| 36 | 1.8.1.8 | B1-B4 Power Supply Commercial Fab |  | 6mo | 2006-01-25 | 2006-07-11 | 35 |  |  | 2004-10-04 | 2004-10-04 | 1d | 174d | 0d | start no earlier than 2005-10-10 |  |  |  |
| 37 | 1.8.1.9 | Receive Spare Control Unit for Programming | milestone | 0d | 2006-05-22 | 2006-05-22 | 32FS-3mo |  |  |  |  |  | 204d | 0d | start no earlier than 2005-10-10 |  |  |  |
| 38 | 1.8.1.10 | Specify Requirements for Sextupole PS's |  | 1w | 2005-11-01 | 2005-11-07 |  |  |  |  |  |  | 316.75d | 4d | start no earlier than 2005-11-01 | Fahmie | 40h |  |
| 39 | 1.8.1.11 | Procurement Process Sextupole PS's |  | 1w | 2005-11-14 | 2005-11-18 | 38 |  |  |  |  |  | 371d |  | start no earlier than 2005-11-14 |  |  |  |
| 40 | 1.8.1.12 | Sextupole Power Supplies Commercial Fab |  | 2mo | 2005-11-21 | 2006-01-20 | 39 |  |  | 2004-10-04 | 2004-10-04 | 1d | 312.75d | 160d | start no earlier than 2005-11-21 |  |  |  |

| ID | WBS | Task | Duration | Start | Finish | Predecessors | Total slack | Free slack |
| --- | --- | --- | --- | --- | --- | --- | --- | --- |
| 41 | 1.8.1.13 | **Quadrupole PS Installation** | 13.25d | 2006-09-04 | 2006-09-21 | 6, 40 | 152.75d |  |
| 42 | 1.8.1.13.1 | **Remove Old PS** | 4.25d | 2006-09-04 | 2006-09-08 |  | 161.75d |  |
| 43 | 1.8.1.13.1.1 | LOTO | 2h | 2006-09-04 | 2006-09-04 |  | 161.75d | 0d |
| 44 | 1.8.1.13.1.2 | Disconnect AC & DC loads | 8h | 2006-09-04 | 2006-09-05 | 43 | 161.75d | 0d |
| 45 | 1.8.1.13.1.3 | Disconnect right of ways & pull back disconnected cables | 8h | 2006-09-05 | 2006-09-06 | 44 | 161.75d | 0d |
| 46 | 1.8.1.13.1.4 | Disconnect cabling | 2h | 2006-09-06 | 2006-09-06 | 45 | 161.75d | 0d |
| 47 | 1.8.1.13.1.5 | Check & insure unit is ready to move | 2h | 2006-09-06 | 2006-09-06 | 46 | 161.75d | 0d |
| 48 | 1.8.1.13.1.6 | Remove unit | 12h | 2006-09-06 | 2006-09-08 | 47 | 161.75d |  |
| 49 | 1.8.1.13.2 | **Install New PS** | 13.25d | 2006-09-04 | 2006-09-21 |  | 152.75d |  |
| 50 | 1.8.1.13.2.1 | Move new unit into place | 12h | 2006-09-04 | 2006-09-05 |  | 152.75d | 0d |
| 51 | 1.8.1.13.2.2 | Secure to floor | 8h | 2006-09-05 | 2006-09-06 | 50 | 152.75d | 0d |
| 52 | 1.8.1.13.2.3 | Install right of ways to unit | 64h | 2006-09-06 | 2006-09-18 | 51 | 152.75d | 0d |
| 53 | 1.8.1.13.2.4 | Connect AC power cables | 8h | 2006-09-18 | 2006-09-19 | 52 | 152.75d | 0d |
| 54 | 1.8.1.13.2.5 | Connect DC output cables | 4h | 2006-09-19 | 2006-09-19 | 53 | 152.75d | 0d |
| 55 | 1.8.1.13.2.6 | Connect all controls cabling | 4h | 2006-09-20 | 2006-09-20 | 54 | 152.75d | 0d |
| 56 | 1.8.1.13.2.7 | Connect water lines | 6h | 2006-09-20 | 2006-09-21 | 55 | 152.75d |  |
| 57 | 1.8.1.14 | **Bend PS Installation** | 50.5d | 2006-07-11 | 2006-09-20 | 36 | 153.5d |  |
| 58 | 1.8.1.14.1 | **Remove Old PS** | 2.5d | 2006-09-07 | 2006-09-11 |  | 153.5d |  |
| 59 | 1.8.1.14.1.1 | LOTO | 2h | 2006-09-07 | 2006-09-07 | 6FS+3d | 153.5d | 0d |
| 60 | 1.8.1.14.1.2 | Disconnect AC & DC loads | 4h | 2006-09-07 | 2006-09-07 | 59 | 153.5d | 0d |
| 61 | 1.8.1.14.1.3 | Disconnect right of ways & pull back disconnected cables | 4h | 2006-09-07 | 2006-09-08 | 60 | 153.5d | 0d |
| 62 | 1.8.1.14.1.4 | Disconnect cabling | 1h | 2006-09-08 | 2006-09-08 | 61 | 153.5d | 0d |
| 63 | 1.8.1.14.1.5 | Check & insure unit is ready to move | 1h | 2006-09-08 | 2006-09-08 | 62 | 153.5d | 0d |
| 64 | 1.8.1.14.1.6 | Remove unit | 8h | 2006-09-08 | 2006-09-11 | 63 | 153.5d | 0d |

| ID | WBS | Task | Type | Duration | Start | Finish | Predecessors | Complete | Remaining | Baseline start | Baseline finish | Baseline duration | Total slack | Free slack | Constraint | Resources | Work | Actual work |
| --- | --- | --- | --- | --- | --- | --- | --- | --- | --- | --- | --- | --- | --- | --- | --- | --- | --- | --- |
| 65 | 1.8.1.14.2 | **Install New PS** |  | 50.5d | 2006-07-12 | 2006-09-20 |  |  |  |  |  |  | 153.5d |  |  |  |  |  |
| 66 | 1.8.1.14.2.1 | Move new unit into place |  | 8h | 2006-09-11 | 2006-09-12 | 64 |  |  |  |  |  | 153.5d | 0d |  |  |  |  |
| 67 | 1.8.1.14.2.2 | Secure to floor |  | 4h | 2006-09-12 | 2006-09-12 | 66 |  |  |  |  |  | 153.5d | 0d |  |  |  |  |
| 68 | 1.8.1.14.2.3 | Install right of ways to unit |  | 32h | 2006-09-13 | 2006-09-18 | 67 |  |  |  |  |  | 153.5d | 0d |  |  |  |  |
| 69 | 1.8.1.14.2.4 | Connect AC power cables |  | 4h | 2006-09-19 | 2006-09-19 | 68 |  |  |  |  |  | 153.5d | 0d |  |  |  |  |
| 70 | 1.8.1.14.2.5 | Connect DC output cables |  | 2h | 2006-09-19 | 2006-09-19 | 69 |  |  |  |  |  | 153.5d | 0d |  |  |  |  |
| 71 | 1.8.1.14.2.6 | Connect all controls cabling |  | 2h | 2006-09-19 | 2006-09-19 | 70 |  |  |  |  |  | 153.5d | 0d |  |  |  |  |
| 72 | 1.8.1.14.2.7 | Connect water lines |  | 4h | 2006-09-20 | 2006-09-20 | 71 |  |  |  |  |  | 153.5d |  |  |  |  |  |
| 73 | 1.8.1.14.2.8 | **Install New Sextupole PS's** |  | 5d | 2006-07-12 | 2006-07-18 |  |  |  |  |  |  | 199d |  |  |  |  |  |
| 74 | 1.8.1.14.2.8.1 | Install PS's |  | 1w | 2006-07-12 | 2006-07-18 |  |  |  |  |  |  | 199d |  | start no earlier than 2006-04-20 |  |  |  |
| 75 | 1.8.1.14.3 | Booster Power Supplies Complete | milestone | 0d | 2006-07-11 | 2006-07-11 |  |  |  |  |  |  | 174d | 66d | start no earlier than 2006-04-26 |  |  |  |
| 77 | 1.8.2 | **Thin Septum Magnet** |  | 312d | 2004-11-23 A | 2006-02-08 |  | 67% | 102.24d | 2004-10-04 | 2004-10-04 | 1d | 283d |  |  |  | 5160h | 3284.4h |
| 78 | 1.8.2.1 | EDI |  | 51w | 2004-11-23 A | 2005-11-14 |  | 58% | 21.42w | 2004-10-04 | 2004-10-04 | 1d | 340d | 59d | finish no earlier than 2005-11-14 | Shuman; Stover | 4080h | 2366.4h |
| 79 | 1.8.2.2 | Magnet - swap out procedure |  | 45d | 2005-05-02 A | 2005-07-01 |  | 85% | 6.75d | 2004-10-04 | 2004-10-04 | 1d | 436d | 155d | start no earlier than 2005-05-02 | Stover; Shuman; Gath | 1080h | 918h |
| 80 | 1.8.2.3 | Magnetic/mechanic measurements at higher fields on spare |  | 30d | 2005-03-16 A | 2005-04-26 A | 88FS+5d | 100% |  |  |  |  |  |  | start no earlier than 2004-11-29 |  |  |  |
| 81 | 1.8.2.4 | Short lifetime testing at higher field |  | 8w | 2005-06-27 A | 2005-08-19 A |  | 100% |  |  |  |  |  |  |  |  |  |  |
| 82 | 1.8.2.5 | Order Supply |  | 1d | 2005-11-16 | 2005-11-16 |  |  |  |  |  |  | 163d | 0d | start no earlier than 2005-11-16 |  |  |  |
| 83 | 1.8.2.6 | Receive Supply | milestone | 0d | 2006-01-25 | 2006-01-25 | 82FS+45d |  |  |  |  |  | 158d | 0d |  |  |  |  |
| 84 | 1.8.2.7 | Power Supplies- KSI upgrade |  | 10d | 2006-01-26 | 2006-02-08 | 83 |  |  | 2004-10-04 | 2004-10-04 | 1d | 158d | 6d | start no earlier than 2005-10-03 |  |  |  |
| 86 | 1.8.3 | **Thick Septum Magnet** |  | 329d | 2004-11-22 A | 2006-03-02 |  | 44% | 184.96d | 2004-10-04 | 2004-10-04 | 1d | 297d |  |  |  |  |  |
| 87 | 1.8.3.1 | EDI |  | 13mo | 2004-11-22 A | 2005-11-18 |  | 58% | 5.46mo | 2004-10-04 | 2004-10-04 | 1d | 336d | 55d | start no earlier than 2004-11-22 |  |  |  |
| 88 | 1.8.3.2 | Magnetic/Mechanic Measurements at Higher Fields on Spare |  | 30ed | 2005-02-07 A | 2005-03-09 A |  | 100% |  | 2004-10-04 | 2004-10-04 | 1d |  |  | start no earlier than 2005-02-07 |  |  |  |
| 89 | 1.8.3.3 | Short lifetime testing at higher field |  | 60ed | 2005-08-19 | 2005-10-18 | 80, 81 |  |  |  |  |  | 1531.88d | 240d |  |  |  |  |
| 90 | 1.8.3.4 | Review Specs and potential manufactureres | milestone | 0d | 2005-09-12 | 2005-09-12 |  |  |  |  |  |  | 336d | 15d | start no earlier than 2005-09-12 |  |  |  |
| 91 | 1.8.3.5 | Order Supply | milestone | 0d | 2005-11-16 | 2005-11-16 | 5, 90 |  |  |  |  |  | 319d | 22d | start no earlier than 2005-11-16 |  |  |  |
| 92 | 1.8.3.6 | Receive Supply | milestone | 0d | 2006-02-17 | 2006-02-17 | 91FS+45d |  |  |  |  |  | 297d | 0d | start no earlier than 2006-02-17 |  |  |  |
| 93 | 1.8.3.7 | Power Supplies - KSI replacement |  | 10d | 2006-02-17 | 2006-03-02 | 84, 92 |  |  | 2004-10-04 | 2004-10-04 | 1d | 297d |  | start no earlier than 2005-11-01 |  |  |  |
| 94 | 1.8.3.8 | Order Caps | milestone | 0d | 2005-10-31 | 2005-10-31 |  |  |  |  |  |  | 136d | 4d | start no earlier than 2005-10-31 |  |  |  |
| 95 | 1.8.3.9 | Receive Caps | milestone | 0d | 2006-01-27 | 2006-01-27 | 94FS+60d |  |  |  |  |  | 131d | 0d | start no earlier than 2006-01-27 |  |  |  |
| 96 | 1.8.3.10 | Power Supplies - replace capacitors |  | 10d | 2006-01-30 | 2006-02-10 | 95 |  |  | 2004-10-04 | 2004-10-04 | 1d | 131d | 0d |  |  |  |  |

Notes:
- 79: Derek, Bill, Greg Morrison, and I need to dope out the exact procedure for swapping out the SR thin septum magnet (worst case magnet) with a ready spare in under one week. Maybe minor 6 week shutdown time to open SR vacuum box to make and confirm some measurements
- 84: Not necessary for long shutdown. The KSI upgrades can be fabbed in the EI shop and insalled 'one at a time' during any normal shutdown day.
- 93: Not necessary for long shutdown. The KSI upgrades can be fabbed in the EI shop and insalled 'one at a time' during any normal shutdown day.
- 96: Not necessary for long shutdown. The spare septa driver we've constructed can be swapped with the existing unit which can be modified on the bench and swapped back in.

| ID | WBS | Task | Type | Duration | Start | Finish | Predecessors | Complete | Remaining | Baseline start | Baseline finish | Baseline duration | Total slack | Free slack | Constraint | Resources | Work |
| --- | --- | --- | --- | --- | --- | --- | --- | --- | --- | --- | --- | --- | --- | --- | --- | --- | --- |
| 98 | 1.8.4 | **Kicker Magnet** |  | 40d | 2005-11-01 | 2006-01-02 |  |  |  | 2004-10-04 | 2004-10-04 | 1d | 310d |  |  |  | 320h |
| 99 | 1.8.4.1 | EDI |  | 15d | 2005-11-01 | 2005-11-21 | 4 |  |  | 2004-10-04 | 2004-10-04 | 1d | 310d | 0d | start no earlier than 2005-11-01 | Ottens | 120h |
| 100 | 1.8.4.2 | Power Supplies - one new interface |  | 5d | 2005-11-22 | 2005-11-28 | 99 |  |  | 2004-10-04 | 2004-10-04 | 1d | 310d | 0d |  | Ottens | 40h |
| 101 | 1.8.4.3 | Power Supplies - HV diode stack |  | 5d | 2005-11-29 | 2005-12-05 | 100 |  |  | 2004-10-04 | 2004-10-04 | 1d | 310d | 0d |  | Ottens | 40h |
| 102 | 1.8.4.4 | Power Supplies - Kicker structure upgades |  | 5d | 2005-12-06 | 2005-12-12 | 101 |  |  | 2004-10-04 | 2004-10-04 | 1d | 310d | 0d |  | Ottens | 40h |
| 103 | 1.8.4.5 | Power Supplies - charge-line upgrades |  | 10d | 2005-12-13 | 2006-01-02 | 102 |  |  | 2004-10-04 | 2004-10-04 | 1d | 310d | 29d |  | Ottens | 80h |
| 105 | 1.8.5 | Booster Pulsed Magnets Complete | milestone | 0d | 2006-02-10 | 2006-02-10 | 103, 96, 87, 89, 78, 79 |  |  |  |  |  | 281d | 173d |  |  |  |
| 107 | 1.4.5 | **RF** |  | 417d | 2005-03-01 A | 2006-10-11 |  | 44% | 233.37d |  |  |  | 138d |  |  |  |  |
| 108 | 1.4.5.0 | Money Available for Procurement | milestone | 0d | 2005-03-01 | 2005-03-01 | 4 |  |  |  |  |  | 273d | 0d |  |  |  |
| 109 | 1.4.5.1 | **EDI Overall System** |  | 389d | 2005-03-01 A | 2006-09-04 |  | 71% | 114.41d |  |  |  | 136d |  |  |  |  |
| 110 | 1.8.6.2.1 | EDI/Specs for Procurements |  | 92d | 2005-03-01 A | 2005-07-06 A |  | 100% |  |  |  |  |  |  | finish no earlier than 2005-06-15 |  |  |
| 111 | 1.8.6.2.2 | Design Review for HVPS and Tranmitter |  | 20d | 2005-06-01 A | 2005-06-28 A | 450FS-3w, 448FS-3w | 100% |  |  |  |  |  |  | finish no earlier than 2005-06-24 |  |  |
| 112 | 1.8.6.2.3 | Procurement Decision for Ceramics | milestone | 0d | 2005-03-14 A | 2005-03-14 A |  | 100% |  |  |  |  |  |  | start no earlier than 2005-03-14 |  |  |
| 113 | 1.8.6.2.4 | Design review for RF Window | milestone | 0d | 2005-05-12 A | 2005-05-12 A |  | 100% |  |  |  |  |  |  | start no earlier than 2005-05-12 |  |  |
| 114 | 1.4.5.1.0 | EDI Overall System |  | 160d | 2005-03-01 A | 2005-10-10 | 108 | 50% | 80d |  |  |  | 365d | 257d |  |  |  |
| 115 | 1.4.5.1.1 | Begin Installation Shutdown | milestone | 0d | 2006-09-04 | 2006-09-04 | 6 |  |  |  |  |  | 108d | 0d |  |  |  |
| 116 | 1.4.5.2 | **High Voltage Power Supply** |  | 298d | 2005-07-07 A | 2006-09-05 |  | 39% | 182.53d |  |  |  | 108d |  |  |  |  |
| 117 | 1.8.6.3.1 | Procurement Process |  | 9.14ew | 2005-07-07 A | 2005-09-09 A | 111FS+7d, 110 | 100% |  |  |  |  |  |  | finish no earlier than 2005-07-25 |  |  |
| 118 | 1.4.5.2.0 | Purchase HVPS |  | 186ed | 2005-09-09 A | 2006-03-14 | 108, 110, 111, 117 | 20% | 148.98ed |  |  |  | 565.93d | 0d | start no earlier than 2005-03-01 |  |  |
| 119 | 1.4.5.2.1 | Removal of existing HVPS |  | 2d | 2006-09-04 | 2006-09-05 | 115 |  |  |  |  |  | 108d | 0d | start no earlier than 2006-04-03 |  |  |
| 120 | 1.4.5.2.2 | **Installation of new HVPS** |  | 30d | 2006-03-28 | 2006-05-09 |  |  |  |  |  |  | 134.06d |  |  |  |  |
| 121 | 1.4.5.2.2.0 | Installation of HVPS |  | 6w | 2006-03-28 | 2006-05-09 | 118FS+2ew |  |  |  |  |  | 134.06d | 0d |  |  |  |
| 122 | 1.4.5.2.2.1 | Installation of HVPS complete | milestone | 0d | 2006-05-09 | 2006-05-09 | 121 |  |  |  |  |  | 134.06d | 0d |  |  |  |
| 123 | 1.4.5.3 | **Final Amplifier/Transmitter** |  | 315d | 2005-07-07 A | 2006-09-27 |  | 41% | 185.48d |  |  |  | 108d |  |  |  |  |
| 124 | 1.8.6.4.1 | Procurement Process |  | 9.14ew | 2005-07-07 A | 2005-09-09 A | 111 | 100% |  |  |  |  |  |  | start no earlier than 2005-07-07 |  |  |
| 125 | 1.4.5.3.0 | Purchase Transmitter System |  | 186ed | 2005-09-09 A | 2006-03-14 | 108, 449, 111, 124, 110 | 16% | 155.6ed |  |  |  | 630.06d | 1.19d | start no earlier than 2005-03-01 |  |  |
| 126 | 1.8.6.4.3 | IOT Procurement Process |  | 9.14ew | 2005-07-07 A | 2005-09-09 | 111FS+7d, 110 | 90% | 0.91ew |  |  |  | 1025.03d | 0d | finish no earlier than 2005-08-22 |  |  |
| 127 | 1.4.5.3.1 | IOT Tube purchase |  | 12ew | 2005-09-09 A | 2005-12-02 | 108, 110, 126, 111 | 36% | 7.71ew |  |  |  | 934.93d | 306.06d | start no earlier than 2005-03-01 |  |  |
| 128 | 1.4.5.3.2 | Removal of existing xmtr |  | 3d | 2006-09-06 | 2006-09-08 | 119 |  |  |  |  |  | 108d | 0d |  |  |  |

Notes:
- 100: Not necessary for long shutdown. The KSI upgrades can be fabbed in the EI shop and installed in one location to test it's functionality. Only one or two units need to be constructed to cover for when we can no longer repair the original KSI's
- 101: Off line job. Stacks can be installed one or two at a time during a normal shutdown day
- 102: Off line job. Each of the kicker magenet structures can be modified during a single shutdown day.
- 103: Don't really need to upgrade the charge lines. Just have the hardware ready to go.

| ID | WBS | Task | Type | Duration | Start | Finish | Predecessors | Complete | Remaining | Total slack | Free slack | Constraint |
| --- | --- | --- | --- | --- | --- | --- | --- | --- | --- | --- | --- | --- |
| 129 | 1.4.5.3.3 | **Temp Install xmtr for testing** |  | 84.94d | 2006-03-28 | 2006-07-25 |  |  |  | 134.06d |  |  |
| 130 | 1.4.5.3.3.0 | Temp Install Xmtr |  | 3ew | 2006-03-28 | 2006-04-18 | 125FS+2ew, 127FS+2ew, 157, 158 |  |  | 628.88d | 62.94d | start no earlier than 2006-03-28 |
| 131 | 1.4.5.3.3.1 | Acceptance Test Xmtr |  | 15d | 2006-05-09 | 2006-05-30 | 130, 122 |  |  | 134.06d | 0d | start no earlier than 2006-05-09 |
| 132 | 1.4.5.3.3.2 | Control System Programming |  | 40d | 2006-05-30 | 2006-07-25 | 131 |  |  | 134.06d | 0d | start no earlier than 2006-05-30 |
| 133 | 1.4.5.3.3.3 | Xmtr tested & Controls Programmed | milestone | 0d | 2006-07-25 | 2006-07-25 | 132 |  |  | 134.06d | 0d | finish no earlier than 2006-07-25 |
| 134 | 1.4.5.3.4 | Reinstall xmtr in final location, test |  | 13d | 2006-09-11 | 2006-09-27 | 128 |  |  | 108d | 0d |  |
| 135 | 1.4.5.4 | **RF Cavity Window** |  | 231.7d | 2005-04-04 A | 2006-02-28 |  | 66% | 79.21d | 259.3d |  |  |
| 136 | 1.8.6.5.1 | Procurement process (ceramics) |  | 1ew | 2005-04-04 A | 2005-04-11 A | 112FS+3ew | 100% |  |  |  | start no earlier than 2005-04-04 |
| 137 | 1.4.5.4.0 | Purchase Ceramics |  | 109ed | 2005-04-11 A | 2005-07-29 A | 108FS+4w, 112, 136 | 100% |  |  |  | start no earlier than 2005-04-11 |
| 138 | 1.8.6.5.3 | Procurement process (manufacture) |  | 1ew | 2005-07-04 A | 2005-07-11 A | 113 | 100% |  |  |  | start no earlier than 2005-07-04 |
| 139 | 1.8.6.5.4 | Ceramics acceptance measurements |  | 6w | 2005-07-29 A | 2005-09-08 A | 137 | 100% |  |  |  |  |
| 140 | 1.8.6.5.5 | Purchase RF Window Assemblies (manufacture) |  | 12.7ew | 2005-09-15 A | 2005-12-13 | 137FS+7w, 113 | 27% | 9.27ew | 1112.17d | 0d | start no earlier than 2005-09-15 |
| 141 | 1.8.6.5.6 | Window's shipping and customs |  | 3w | 2005-12-13 | 2006-01-10 | 140 |  |  | 259.3d | 0d |  |
| 142 | 1.4.5.4.1 | **Titanium Nitride Coat** |  | 25d | 2006-01-10 | 2006-02-14 | 141 |  |  | 259.3d |  |  |
| 143 | 1.4.5.4.1.0 | Titanium Nitride Coating |  | 20d | 2006-01-10 | 2006-02-07 |  |  |  | 259.3d | 0d | start no earlier than 2006-01-09 |
| 144 | 1.4.5.4.1.1 | RBS Measurements |  | 5d | 2006-02-07 | 2006-02-14 | 143 |  |  | 259.3d | 0d | start no earlier than 2006-02-06 |
| 145 | 1.4.5.4.2 | Power Test Windows |  | 2w | 2006-02-14 | 2006-02-28 | 144 |  |  | 259.3d | 0d | start no earlier than 2006-02-13 |
| 146 | 1.4.5.4.3 | Windows Ready for Installation | milestone | 0d | 2006-02-28 | 2006-02-28 | 145 |  |  | 259.3d | 151.3d | finish no earlier than 2006-02-24 |
| 147 | 1.4.5.5 | **RF Transmission Line** |  | 258d | 2005-10-03 | 2006-10-04 |  |  |  | 108d |  |  |
| 148 | 1.4.5.5.0 | Purchase Components |  | 12w | 2005-10-03 | 2005-12-23 | 108 |  |  | 306d | 198d | start no earlier than 2005-10-03 |
| 149 | 1.4.5.5.9 | Remove Old/Install New Line |  | 5d | 2006-09-28 | 2006-10-04 | 134, 146, 148, 159 |  |  | 108d | 0d | start no earlier than 2006-04-27 |
| 150 | 1.4.5.6 | **Controls and Interlocks** |  | 263d | 2005-10-03 | 2006-10-11 |  |  |  | 108d |  |  |
| 151 | 1.4.5.6.0 | Purchase PLC |  | 8w | 2005-10-03 | 2005-11-25 | 108, 5 |  |  | 306d | 171.94d |  |
| 152 | 1.4.5.6.1 | Program PLC |  | 4w | 2006-07-25 | 2006-08-22 | 133, 151 |  |  | 134.06d | 0d |  |
| 153 | 1.4.5.6.8 | Testing |  | 1w | 2006-10-05 | 2006-10-11 | 149, 152, 454 |  |  | 108d | 0d |  |
| 154 | 1.4.5.6.10 | RF System Ready for Beam | milestone | 0d | 2006-10-11 | 2006-10-11 | 153 |  |  | 108d | 0d | start no earlier than 2004-12-02 |

| ID | WBS | Task | Type | Duration | Start | Finish | Predecessors | Baseline start | Baseline finish | Baseline duration | Total slack | Free slack | Constraint |
| --- | --- | --- | --- | --- | --- | --- | --- | --- | --- | --- | --- | --- | --- |
| 155 | 1.4.5.7 | **Utilities** |  | 35d | 2005-10-31 | 2005-12-16 |  |  |  |  | 216d |  |  |
| 156 | 1.4.5.7.1 | Corrdination |  | 25d | 2005-10-31 | 2005-12-02 |  |  |  |  | 221d | 0d | start no earlier than 2005-10-31 |
| 157 | 1.4.5.7.2 | 480 VAC |  | 20d | 2005-11-21 | 2005-12-16 | 156FS-2ew |  |  |  | 221d | 72d | start no earlier than 2005-11-21 |
| 158 | 1.4.5.7.3 | LCW |  | 7d | 2005-11-21 | 2005-11-29 | 156FS-2ew |  |  |  | 234d | 85d | start no earlier than 2005-11-21 |
| 159 | 1.4.5.8 | Structure Core Drilling |  | 1d | 2006-09-11 | 2006-09-11 | 128 |  |  |  | 120d | 12d | start no earlier than 2006-04-27 |
| 160 | 1.4.5.9 | Spares |  | 140d | 2005-10-03 | 2006-04-21 |  |  |  |  | 261d |  | start no earlier than 2005-10-03 |
| 161 | 1.8.6.11 | **RSS Installation** |  | 196d | 2005-11-30 | 2006-09-06 |  |  |  |  | 133d |  |  |
| 162 | 1.8.6.11.1 | **EDI** |  | 10d | 2005-11-30 | 2005-12-13 |  |  |  |  | 162d |  |  |
| 163 | 1.8.6.11.1.1 | Produce Drawing Packages |  | 1w | 2005-11-30 | 2005-12-06 | 355 |  |  |  | 167d | 0d | start no earlier than 2005-11-02 |
| 164 | 1.8.6.11.1.2 | Place procurements and write job orders |  | 1w | 2005-12-07 | 2005-12-13 | 163 |  |  |  | 321d | 188d |  |
| 165 | 1.8.6.11.2 | Installation |  | 2d | 2006-09-04 | 2006-09-05 | 6, 164 |  |  |  | 133d | 0d |  |
| 166 | 1.8.6.11.3 | Testing |  | 1d | 2006-09-06 | 2006-09-06 | 165 |  |  |  | 133d | 25d |  |
| 168 | 1.8.6.12 | Booster RF Complete | milestone | 0d | 2006-10-11 | 2006-10-11 | 166, 154, 114 |  |  |  | 108d | 0d |  |
| 170 | 1.8.7 | **Diagnostics** |  | 381d | 2005-10-03 | 2007-03-26 |  | 2004-10-04 | 2004-10-04 | 1d | 20d |  |  |
| 171 | 1.8.7.1 | **Bunch Cleaning (Unapproved Scope)** |  | 126d | 2006-10-02 | 2007-03-26 | 7 | 2004-10-04 | 2004-10-04 | 1d | 0d |  |  |
| 172 | 1.8.7.1.1 | **Vertical Kicker** |  | 92d | 2006-10-02 | 2007-02-06 |  |  |  |  | 34d |  |  |
| 173 | 1.8.7.1.1.1 | EDI |  | 4w | 2006-10-02 | 2006-10-27 | 4 |  |  |  | 34d | 0d |  |
| 174 | 1.8.7.1.1.2 | Material Procurement |  | 2w | 2006-10-30 | 2006-11-10 | 173, 5 |  |  |  | 34d | 0d |  |
| 175 | 1.8.7.1.1.3 | Fabrication |  | 8w | 2006-11-13 | 2007-01-05 | 174 |  |  |  | 34d | 0d |  |
| 176 | 1.8.7.1.1.4 | Testing |  | 4w | 2007-01-08 | 2007-02-02 | 175 |  |  |  | 34d | 0d |  |
| 177 | 1.8.7.1.1.5 | Installation |  | 2d | 2007-02-05 | 2007-02-06 | 176, 6 |  |  |  | 34d |  |  |
| 178 | 1.8.7.1.2 | **High Power Amplifier** |  | 96d | 2006-10-02 | 2007-02-12 |  |  |  |  | 30d |  |  |
| 179 | 1.8.7.1.2.1 | Specification and Order |  | 1w | 2006-10-02 | 2006-10-06 | 5 |  |  |  | 30d | 0d |  |
| 180 | 1.8.7.1.2.2 | Receive Amp |  | 1d | 2007-01-29 | 2007-01-29 | 179FS+16w |  |  |  | 30d | 0d |  |
| 181 | 1.8.7.1.2.3 | Installation |  | 2w | 2007-01-30 | 2007-02-12 | 180 |  |  |  | 30d |  |  |

| ID | WBS | Task | Type | Duration | Start | Finish | Predecessors | Total slack | Free slack |
| --- | --- | --- | --- | --- | --- | --- | --- | --- | --- |
| 182 | 1.8.7.1.3 | **Vertical Scraper** |  | 106d | 2006-10-09 | 2007-03-05 |  | 0d |  |
| 183 | 1.8.7.1.3.1 | EDI |  | 6w | 2006-10-09 | 2006-11-17 | 437, 5 | 0d |  |
| 184 | 1.8.7.1.3.2 | Design Review | milestone | 0d | 2006-11-17 | 2006-11-17 | 183 | 0d |  |
| 185 | 1.8.7.1.3.3 | Fabrication |  | 12w | 2006-11-20 | 2007-02-09 | 184 | 0d |  |
| 186 | 1.8.7.1.3.4 | Installation |  | 2d | 2007-02-12 | 2007-02-13 | 185 | 24d | 9d |
| 187 | 1.8.7.1.3.5 | Testing |  | 1w | 2007-02-27 | 2007-03-05 | 186, 441 | 15d |  |
| 188 | 1.8.7.1.4 | **Cleaning Electronics** |  | 65d | 2006-10-02 | 2006-12-29 |  | 61d |  |
| 189 | 1.8.7.1.4.1 | EDI |  | 4w | 2006-10-02 | 2006-10-27 | 5 | 61d | 0d |
| 190 | 1.8.7.1.4.2 | Component Procurement |  | 4w | 2006-10-30 | 2006-11-24 | 189 | 61d | 0d |
| 191 | 1.8.7.1.4.3 | Fabrication |  | 2w | 2006-11-27 | 2006-12-08 | 190 | 61d | 0d |
| 192 | 1.8.7.1.4.4 | Testing |  | 2w | 2006-12-11 | 2006-12-22 | 191 | 61d | 0d |
| 193 | 1.8.7.1.4.5 | Installation |  | 1w | 2006-12-25 | 2006-12-29 | 192, 6 | 61d |  |
| 194 | 1.8.7.1.5 | **Function Generator** |  | 95d | 2006-10-02 | 2007-02-09 |  | 31d |  |
| 195 | 1.8.7.1.5.1 | Specification and Order |  | 1w | 2006-10-02 | 2006-10-06 | 5 | 31d | 0d |
| 196 | 1.8.7.1.5.2 | Receive Generator | milestone | 0d | 2007-01-26 | 2007-01-26 | 195FS+16w | 31d | 0d |
| 197 | 1.8.7.1.5.3 | Installation |  | 2w | 2007-01-29 | 2007-02-09 | 196 | 31d |  |
| 198 | 1.8.7.1.6 | Bunch Cleaning Complete | milestone | 0d | 2007-03-26 | 2007-03-26 | 197, 193, 187, 181, 177, 446 | 0d |  |
| 199 | 1.8.7.2 | **Tune Measurement System** |  | 347d | 2005-10-03 | 2007-02-06 |  | 54d |  |
| 200 | 1.8.7.2.1 | **Horizontal Kicker (Unapproved Scope)** |  | 92d | 2006-10-02 | 2007-02-06 | 7 | 54d |  |
| 201 | 1.8.7.2.1.1 | EDI |  | 4w | 2006-10-02 | 2006-10-27 | 5 | 54d | 0d |
| 202 | 1.8.7.2.1.2 | Material Procurement |  | 2w | 2006-10-30 | 2006-11-10 | 201 | 54d | 0d |
| 203 | 1.8.7.2.1.3 | Fabrication |  | 8w | 2006-11-13 | 2007-01-05 | 202 | 54d | 0d |
| 204 | 1.8.7.2.1.4 | Testing |  | 4w | 2007-01-08 | 2007-02-02 | 203 | 54d | 0d |
| 205 | 1.8.7.2.1.5 | Installation |  | 2d | 2007-02-05 | 2007-02-06 | 204 | 54d | 34d |

| ID | WBS | Task | Type | Duration | Start | Finish | Predecessors | Baseline start | Baseline finish | Baseline duration | Total slack | Free slack | Constraint | Resources | Work |
| --- | --- | --- | --- | --- | --- | --- | --- | --- | --- | --- | --- | --- | --- | --- | --- |
| 206 | 1.8.7.2.2 | **Oscilloscope** |  | 60d | 2005-10-03 | 2005-12-23 |  |  |  |  | 281d |  |  |  |  |
| 207 | 1.8.7.2.2.1 | Specification and Order |  | 2w | 2005-10-03 | 2005-10-14 | 4, 5 |  |  |  | 286d | 0d |  |  |  |
| 208 | 1.8.7.2.2.2 | Receive Oscillioscope | milestone | 0d | 2005-12-09 | 2005-12-09 | 207FS+8w |  |  |  | 286d | 0d |  |  |  |
| 209 | 1.8.7.2.2.3 | Installation |  | 2w | 2005-12-12 | 2005-12-23 | 208 |  |  |  | 286d | 0d |  |  |  |
| 210 | 1.8.7.3 | **BPMs (Unapproved Scope)** |  | 56d | 2006-10-02 | 2006-12-18 | 7 |  |  |  | 90d |  |  |  |  |
| 211 | 1.8.7.3.1 | Test with Spare SR Electronics |  | 1d | 2006-10-02 | 2006-10-02 |  |  |  |  | 90d | 0d | start no earlier than 2005-01-17 |  |  |
| 212 | 1.8.7.3.2 | EDI |  | 1w | 2006-10-03 | 2006-10-09 | 211, 4 |  |  |  | 90d | 0d |  |  |  |
| 213 | 1.8.7.3.3 | Procurement |  | 8w | 2006-10-10 | 2006-12-04 | 5, 212 |  |  |  | 90d | 0d |  |  |  |
| 214 | 1.8.7.3.4 | Installation |  | 2w | 2006-12-05 | 2006-12-18 | 213 |  |  |  | 90d | 70d |  |  |  |
| 216 | 1.8.7.4 | Booster Diagnostics Complete | milestone | 0d | 2007-03-26 | 2007-03-26 | 214, 209, 205, 198 |  |  |  | 20d |  |  |  |  |
| 218 | 1.9 | **BTS** |  | 451d | 2005-07-05 | 2007-04-03 |  | 2004-10-04 | 2004-10-04 | 1d | 14d |  |  |  | 400h |
| 219 | 1.9.1 | **Diagnostics** |  | 451d | 2005-07-05 | 2007-04-03 |  | 2004-10-04 | 2004-10-04 | 1d | 14d |  |  |  | 400h |
| 220 | 1.9.1.1 | **Tune Up Dump** |  | 92d | 2005-10-03 | 2006-02-14 | 5 | 2004-10-04 | 2004-10-04 | 1d | 304d |  |  |  | 240h |
| 221 | 1.9.1.1.1 | EDI |  | 6w | 2005-10-03 | 2005-11-11 |  |  |  |  | 304d | 0d |  | Mechanical Engineering | 240h |
| 222 | 1.9.1.1.2 | Fabrication |  | 12w | 2005-11-14 | 2006-02-10 | 221 |  |  |  | 304d | 0d |  |  |  |
| 223 | 1.9.1.1.3 | Installation |  | 2d | 2006-02-13 | 2006-02-14 | 222 |  |  |  | 304d | 0d |  |  |  |
| 224 | 1.9.1.2 | **Synchrotron Radiation Monitors** |  | 451d | 2005-07-05 | 2007-04-03 |  |  |  |  | 14d |  |  |  | 160h |
| 225 | 1.9.1.2.1 | **Monitor on B1 Bend** |  | 52d | 2005-07-05 | 2005-09-14 |  |  |  |  | 281d |  |  |  | 160h |
| 226 | 1.9.1.2.1.1 | EDI |  | 2w | 2005-07-05 | 2005-07-18 | 4 |  |  |  | 281d | 0d | start no earlier than 2005-07-05 | Scarvie; Mechanical Engineering | 160h |
| 227 | 1.9.1.2.1.2 | Component Procurement |  | 4w | 2005-07-19 | 2005-08-15 | 226 |  |  |  | 286d | 0d |  |  |  |
| 228 | 1.9.1.2.1.3 | Fabrication |  | 3w | 2005-07-19 | 2005-08-08 | 226 |  |  |  | 291d | 5d |  |  |  |
| 229 | 1.9.1.2.1.4 | Mechanical Installation |  | 2d | 2005-08-16 | 2005-08-17 | 228, 227 |  |  |  | 286d | 0d |  |  |  |
| 230 | 1.9.1.2.1.5 | Test and Evaluate |  | 4w | 2005-08-18 | 2005-09-14 | 229 |  |  |  | 286d | 0d |  |  |  |
| 231 | 1.9.1.2.1.6 | Determine Value of B3 Monitor | milestone | 0d | 2005-09-14 | 2005-09-14 | 230 |  |  |  | 286d | 272d |  |  |  |

| ID | WBS | Task | Type | Duration | Start | Finish | Predecessors | Baseline start | Baseline finish | Baseline duration | Total slack | Free slack |
| --- | --- | --- | --- | --- | --- | --- | --- | --- | --- | --- | --- | --- |
| 232 | 1.9.1.2.2 | **Monitor on B3 Bend (Unapproved Scope)** |  | 132d | 2006-10-02 | 2007-04-03 | 7 |  |  |  | 14d |  |
| 233 | 1.9.1.2.2.1 | EDI |  | 8w | 2006-10-02 | 2006-11-24 | 231, 5 |  |  |  | 14d | 0d |
| 234 | 1.9.1.2.2.2 | Component Procurement |  | 6w | 2006-11-27 | 2007-01-05 | 233 |  |  |  | 14d | 0d |
| 235 | 1.9.1.2.2.3 | Fabrication |  | 12w | 2007-01-08 | 2007-03-30 | 234 |  |  |  | 14d | 0d |
| 236 | 1.9.1.2.2.4 | Mechanical Installation |  | 2d | 2007-04-02 | 2007-04-03 | 234, 235 |  |  |  | 14d |  |
| 237 | 1.9.1.3 | **BIM 2 (Unapproved Scope)** |  | 60d | 2006-11-27 | 2007-02-16 | 7 |  |  |  | 46d |  |
| 238 | 1.9.1.3.1 | Component Procurement |  | 6w | 2006-11-27 | 2007-01-05 | 21 |  |  |  | 46d | 0d |
| 239 | 1.9.1.3.2 | Fabrication |  | 2w | 2007-01-08 | 2007-01-19 | 238 |  |  |  | 46d | 0d |
| 240 | 1.9.1.3.3 | Test |  | 4w | 2007-01-22 | 2007-02-16 | 239 |  |  |  | 46d | 0d |
| 242 | 1.9.1.4 | BTS Diagnostics Complete | milestone | 0d | 2007-02-16 | 2007-02-16 | 223, 240 |  |  |  | 46d |  |
| 244 | 1.9.2 | **B1-B4 Bend Power Supplies** |  | 320.75d | 2005-07-13 | 2006-10-11 |  | 2004-10-04 | 2004-10-04 | 1d | 108.25d |  |
| 245 | 1.9.2.1 | Procurement Process/Order |  | 6w | 2005-07-13 | 2005-08-23 | 30 |  |  |  | 241.25d | 0d |
| 246 | 1.9.2.2 | B1-B4 Bend Power Supplies Commerical Fab |  | 7mo | 2005-08-24 | 2006-03-14 | 403, 245 | 2004-10-04 | 2004-10-04 | 1d | 236.25d | 128d |
| 247 | 1.9.2.3 | **Installation** |  | 22.75d | 2006-09-11 | 2006-10-11 | 6FS+5d, 246 |  |  |  | 108.25d |  |
| 248 | 1.9.2.3.1 | **Remove Old PS** |  | 7.25d | 2006-09-11 | 2006-09-20 |  |  |  |  | 108.25d |  |
| 249 | 1.9.2.3.1.1 | LOTO |  | 2h | 2006-09-11 | 2006-09-11 |  |  |  |  | 108.25d | 0d |
| 250 | 1.9.2.3.1.2 | Disconnect AC & DC loads |  | 16h | 2006-09-11 | 2006-09-13 | 249 |  |  |  | 108.25d | 0d |
| 251 | 1.9.2.3.1.3 | Disconnect right of ways & pull back disconnected cables |  | 16h | 2006-09-13 | 2006-09-15 | 250 |  |  |  | 108.25d | 0d |
| 252 | 1.9.2.3.1.4 | Disconnect cabling |  | 4h | 2006-09-15 | 2006-09-15 | 251 |  |  |  | 108.25d | 0d |
| 253 | 1.9.2.3.1.5 | Check & insure unit is ready to move |  | 4h | 2006-09-15 | 2006-09-18 | 252 |  |  |  | 108.25d | 0d |
| 254 | 1.9.2.3.1.6 | Remove unit |  | 16h | 2006-09-18 | 2006-09-20 | 253 |  |  |  | 108.25d | 0d |
| 255 | 1.9.2.3.2 | **Install New PS** |  | 15.5d | 2006-09-20 | 2006-10-11 |  |  |  |  | 108.25d |  |
| 256 | 1.9.2.3.2.1 | Move new unit into place |  | 16h | 2006-09-20 | 2006-09-22 | 254 |  |  |  | 108.25d | 0d |
| 257 | 1.9.2.3.2.2 | Secure to floor |  | 12h | 2006-09-22 | 2006-09-25 | 256 |  |  |  | 108.25d | 0d |
| 258 | 1.9.2.3.2.3 | Install right of ways to unit |  | 64h | 2006-09-25 | 2006-10-05 | 257 |  |  |  | 108.25d | 0d |
| 259 | 1.9.2.3.2.4 | Connect AC power cables |  | 16h | 2006-10-05 | 2006-10-09 | 258 |  |  |  | 108.25d | 0d |
| 260 | 1.9.2.3.2.5 | Connect DC output cables |  | 4h | 2006-10-09 | 2006-10-10 | 259 |  |  |  | 108.25d | 0d |
| 261 | 1.9.2.3.2.6 | Connect all controls cabling |  | 4h | 2006-10-10 | 2006-10-10 | 260 |  |  |  | 108.25d | 0d |
| 262 | 1.9.2.3.2.7 | Connect water lines |  | 8h | 2006-10-10 | 2006-10-11 | 261 |  |  |  | 108.25d | 0d |
| 264 | 1.9.2.4 | BTS Power Supplies Complete | milestone | 0d | 2006-10-11 | 2006-10-11 | 262 |  |  |  | 108.25d | 0.25d |

| ID | WBS | Task | Type | Duration | Start | Finish | Predecessors | Complete | Remaining | Baseline start | Baseline finish | Baseline duration | Total slack | Free slack | Constraint | Resources | Work | Actual work |
| --- | --- | --- | --- | --- | --- | --- | --- | --- | --- | --- | --- | --- | --- | --- | --- | --- | --- | --- |
| 266 | 1.10 | **Storage Ring** |  | 645d | 2004-10-04 A | 2007-03-30 |  | 30% | 451.48d | 2004-10-04 | 2004-10-04 | 1d | 16d |  |  |  | 11560h | 16h |
| 268 | 1.10.1 | **Thin Septum Magnet** |  | 329d | 2004-11-22 A | 2006-03-02 |  | 54% | 152.7d | 2004-10-04 | 2004-10-04 | 1d | 297d |  |  |  |  |  |
| 269 | 1.10.1.1 | EDI |  | 51w | 2004-11-22 A | 2005-11-11 |  | 58% | 21.42w | 2004-10-04 | 2004-10-04 | 1d | 285d | 2d | start no earlier than 2004-11-22 |  |  |  |
| 270 | 1.10.1.2 | Order Supply |  | 1d | 2005-11-16 | 2005-11-16 | 269, 5, 90 |  |  |  |  |  | 288d | 21d | start no earlier than 2005-11-16 |  |  |  |
| 271 | 1.10.1.3 | Receive Supply | milestone | 0d | 2006-02-17 | 2006-02-17 | 270FS+45d |  |  |  |  |  | 267d | 0d | start no earlier than 2006-02-17 |  |  |  |
| 272 | 1.10.1.4 | Power Supplies - KSI replacement |  | 10d | 2006-02-17 | 2006-03-02 | 271 |  |  | 2004-10-04 | 2004-10-04 | 1d | 267d | 135d | start no earlier than 2005-11-01 |  |  |  |
| 273 | 1.10.1.5 | Order Caps | milestone | 0d | 2005-10-31 | 2005-10-31 |  |  |  |  |  |  | 326d | 6d | start no earlier than 2005-10-31 |  |  |  |
| 274 | 1.10.1.6 | Receive Caps | milestone | 0d | 2006-01-31 | 2006-01-31 | 273FS+60d |  |  |  |  |  | 320d |  | start no earlier than 2006-01-31 |  |  |  |
| 275 | 1.10.1.7 | Power Supplies- KSI upgrade |  | 10d | 2006-02-13 | 2006-02-24 | 96 |  |  | 2004-10-04 | 2004-10-04 | 1d | 131d | 0d | start no earlier than 2005-12-01 |  |  |  |
| 277 | 1.10.2 | **Thick Septum Magnet** |  | 340d | 2004-11-22 A | 2006-03-17 |  | 53% | 161.05d | 2004-10-04 | 2004-10-04 | 1d | 256d |  |  |  |  |  |
| 278 | 1.10.2.1 | EDI |  | 51w | 2004-11-22 A | 2005-11-11 |  | 58% | 21.42w | 2004-10-04 | 2004-10-04 | 1d | 285d | 2d | start no earlier than 2004-11-22 |  |  |  |
| 279 | 1.10.2.2 | Order Supply |  | 1d | 2005-11-16 | 2005-11-16 | 278, 5, 90 |  |  |  |  |  | 288d | 21d | start no earlier than 2005-11-16 |  |  |  |
| 280 | 1.10.2.3 | Receive Supply | milestone | 0d | 2006-02-17 | 2006-02-17 | 279FS+45d |  |  |  |  |  | 267d | 0d | start no earlier than 2006-02-17 |  |  |  |
| 281 | 1.10.2.4 | Power Supplies - KSI replacement |  | 10d | 2006-02-17 | 2006-03-02 | 280 |  |  | 2004-10-04 | 2004-10-04 | 1d | 267d | 135d | start no earlier than 2005-11-01 |  |  |  |
| 282 | 1.10.2.5 | Order Caps | milestone | 0d | 2005-10-31 | 2005-10-31 |  |  |  |  |  |  | 166d | 0d | start no earlier than 2005-10-31 |  |  |  |
| 283 | 1.10.2.6 | Receive Caps | milestone | 0d | 2006-01-27 | 2006-01-27 | 282FS+60d |  |  |  |  |  | 161d | 30d |  |  |  |  |
| 284 | 1.10.2.7 | Power Supplies - KSI replacement |  | 10d | 2006-02-27 | 2006-03-10 | 275 |  |  | 2004-10-04 | 2004-10-04 | 1d | 131d | 0d | start no earlier than 2006-01-03 |  |  |  |
| 285 | 1.10.2.8 | Power Supplies - replace capacitors |  | 5d | 2006-03-13 | 2006-03-17 | 284, 283 |  |  | 2004-10-04 | 2004-10-04 | 1d | 131d | 0d |  |  |  |  |
| 287 | 1.10.3 | Install power supplies during 2 day shutdowns |  | 25w | 2006-03-20 | 2006-09-08 | 285, 275, 96, 84 |  |  |  |  |  | 131d | 0d |  |  |  |  |
| 289 | 1.10.4 | Storage Ring Pulsed Magnets Complete | milestone | 0d | 2006-09-08 | 2006-09-08 | 285, 281, 272, 287 |  |  |  |  |  | 131d | 23d |  |  |  |  |
| 291 | 1.10.5 | **Radiation Protection** |  | 516d | 2004-10-04 A | 2006-10-02 |  | 28% | 369.23d | 2004-10-04 | 2004-10-04 | 1d | 145d |  |  |  | 11440h | 16h |
| 292 | 1.10.5.1 | **Radiation level minimization** |  | 240d | 2004-12-06 A | 2005-11-04 |  | 95% | 12.63d |  |  |  | 285d |  |  |  | 480h |  |
| 293 | 1.10.5.1.1 | Fab Bremsstrahlung Shielding |  | 12w | 2004-12-06 A | 2005-02-25 A |  | 100% |  |  |  |  |  |  | start no earlier than 2004-12-06 |  |  |  |
| 294 | 1.10.5.1.2 | Receive DOE Approval for FSAD Change for BL 4.0 Tests | milestone | 0d | 2005-02-07 A | 2005-02-07 A |  | 100% |  |  |  |  |  |  | start no earlier than 2005-02-07 |  |  |  |
| 295 | 1.10.5.1.3 | Conduct radiation level studies with various mis-settings of injection |  | 100ed | 2005-02-28 A | 2005-06-08 A | 294, 293 | 100% |  |  |  |  |  |  | start no earlier than 2005-02-28 |  |  |  |
| 296 | 1.10.5.1.4 | Document radiation test results |  | 4w | 2005-10-10 | 2005-11-04 | 295 |  |  |  |  |  | 285d | 0d | start no earlier than 2005-10-10 | Nishimura; Robin; Steier | 480h |  |
| 297 | 1.10.5.1.5 | Review findings and determine plan | milestone | 0d | 2005-11-04 | 2005-11-04 | 296 |  |  |  |  |  | 290d | 161d |  |  |  |  |

Notes:
- 272: Not necessary for long shutdown. The KSI upgrades can be fabbed in the EI shop and insalled 'one at a time' during any normal shutdown day.
- 275: Not necessary for long shutdown. The KSI upgrades can be fabbed in the EI shop and insalled 'one at a time' during any normal shutdown day.
- 281: Not necessary for long shutdown. The KSI upgrades can be fabbed in the EI shop and insalled 'one at a time' during any normal shutdown day.
- 284: Not necessary for long shutdown. The KSI upgrades can be fabbed in the EI shop and insalled 'one at a time' during any normal shutdown day.
- 285: Not necessary for long shutdown. The spare septa driver we've constructed can be swapped with the existing unit which can be modified on the bench and swapped back in.

| ID | WBS | Task | Type | Duration | Start | Finish | Predecessors | Complete | Remaining | Baseline start | Baseline finish | Baseline duration | Total slack | Free slack | Constraint | Resources | Work |
| --- | --- | --- | --- | --- | --- | --- | --- | --- | --- | --- | --- | --- | --- | --- | --- | --- | --- |
| 298 | 1.10.5.2 | **Collimation System** |  | 380d | 2004-12-06 A | 2006-05-26 |  | 37% | 240.64d | 2004-10-04 | 2004-10-04 | 1d | 236d |  |  |  | 2080h |
| 299 | 1.10.5.2.1 | **BTS Double Sided Collimator** |  | 155d | 2005-10-17 | 2006-05-26 |  |  |  |  |  |  | 236d |  |  |  | 480h |
| 300 | 1.10.5.2.1.1 | Decide whether to implement plan |  | 2w | 2005-10-17 | 2005-10-28 |  |  |  |  |  |  | 236d | 0d | start no earlier than 2005-10-17 | Steier; Robin; Donahue; Duarte | 320h |
| 301 | 1.10.5.2.1.2 | Determine locations |  | 2w | 2005-10-31 | 2005-11-11 | 300 |  |  |  |  |  | 236d | 0d |  | Nishimura; Donahue | 160h |
| 302 | 1.10.5.2.1.3 | Finalize Design of Double Sided Collimator for BTS |  | 30d | 2005-11-14 | 2005-12-23 | 5, 301 |  |  |  |  |  | 241d | 0d | start no earlier than 2004-12-06 |  |  |
| 303 | 1.10.5.2.1.4 | Design Review | milestone | 0d | 2005-12-23 | 2005-12-23 | 302 |  |  |  |  |  | 241d | 0d |  |  |  |
| 304 | 1.10.5.2.1.5 | Fabricate Double Sided Collimator for BTS |  | 60d | 2006-01-02 | 2006-03-24 | 303 |  |  |  |  |  | 236d | 0d |  |  |  |
| 305 | 1.10.5.2.1.6 | Installation |  | 1w | 2006-03-27 | 2006-03-31 | 304 |  |  |  |  |  | 236d | 0d |  |  |  |
| 306 | 1.10.5.2.1.7 | Testing and beam measurements |  | 8w | 2006-04-03 | 2006-05-26 | 305 |  |  |  |  |  | 236d |  |  |  |  |
| 307 | 1.10.5.2.2 | **SR Vertical Scraper** |  | 338d | 2004-12-06 A | 2006-03-29 |  | 57% | 146.39d |  |  |  | 187d |  |  |  | 1600h |
| 308 | 1.10.5.2.2.1 | **Prototype** |  | 240d | 2004-12-06 A | 2005-11-04 |  | 87% | 30.77d |  |  |  | 285d |  |  |  | 480h |
| 309 | 1.10.5.2.2.1.1 | Finalize Design of Vertical Scrapers for SR |  | 30d | 2004-12-06 A | 2005-01-14 A |  | 100% |  |  |  |  |  |  | start no earlier than 2004-12-06 |  |  |
| 310 | 1.10.5.2.2.1.2 | Design Review | milestone | 0d | 2005-01-14 A | 2005-01-14 A | 309 | 100% |  |  |  |  |  |  |  |  |  |
| 311 | 1.10.5.2.2.1.3 | Fabricate |  | 60d | 2005-01-17 A | 2005-04-08 A | 310 | 100% |  |  |  |  |  |  |  |  |  |
| 312 | 1.10.5.2.2.1.4 | Installation |  | 1w | 2005-05-02 A | 2005-05-06 A | 311, 427 | 100% |  |  |  |  |  |  |  |  |  |
| 313 | 1.10.5.2.2.1.5 | Test Operations of Scraper in SR |  | 1d | 2005-05-09 A | 2005-05-09 A | 312 | 100% |  |  |  |  |  |  |  |  |  |
| 314 | 1.10.5.2.2.1.6 | Repeat radiation level studies |  | 8w | 2005-06-06 A | 2005-07-29 A | 312, 313, 428 | 100% |  |  |  |  |  |  | start no earlier than 2005-06-06 |  |  |
| 315 | 1.10.5.2.2.1.7 | Document radiation test results |  | 4w | 2005-10-10 | 2005-11-04 | 314 |  |  |  |  |  | 285d | 138d | start no earlier than 2005-10-10 | Nishimura; Robin; Steier | 480h |
| 316 | 1.10.5.2.2.2 | **Additional Scrapers** |  | 143d | 2005-09-05 A | 2006-03-29 |  | 20% | 115.07d |  |  |  | 187d |  |  |  | 1120h |
| 317 | 1.10.5.2.2.2.1 | EDI and Documentation |  | 1w | 2005-09-05 A | 2005-09-09 A | 313 | 100% |  |  |  |  |  |  | start no earlier than 2005-09-05 |  |  |
| 318 | 1.10.5.2.2.2.2 | Fabricate |  | 60d | 2005-09-12 A | 2005-12-02 | 317 | 33% | 40d |  |  |  | 202d | 15d | start no earlier than 2005-09-12 |  |  |
| 319 | 1.10.5.2.2.2.3 | Installation |  | 3d | 2006-01-02 | 2006-01-04 | 318 |  |  |  |  |  | 187d | 0d | start no earlier than 2006-01-02 |  |  |
| 320 | 1.10.5.2.2.2.4 | Additional testing with BL 4.0 |  | 8w | 2006-01-05 | 2006-03-01 | 319 |  |  |  |  |  | 187d | 0d |  | Robin; Steier | 640h |
| 321 | 1.10.5.2.2.2.5 | Document radiation test results |  | 4w | 2006-03-02 | 2006-03-29 | 320 |  |  |  |  |  | 187d | 40d | start no earlier than 2005-10-10 | Nishimura; Robin; Steier | 480h |

| ID | WBS | Task | Duration | Start | Finish | Predecessors | Baseline start | Baseline finish | Baseline duration | Total slack | Free slack | Constraint | Resources | Work |
| --- | --- | --- | --- | --- | --- | --- | --- | --- | --- | --- | --- | --- | --- | --- |
| 322 | 1.10.5.3 | **Injection Interlock** | 386d | 2005-04-04 | 2006-10-02 |  | 2004-10-04 | 2004-10-04 | 1d | 145d |  |  |  | 6040h |
| 323 | 1.10.5.3.1 | **Storage Ring Current Monitoring** | 312d | 2005-04-04 | 2006-06-20 |  |  |  |  | 219d |  |  |  | 5160h |
| 324 | 1.10.5.3.1.1 | Testing of Second Current Monitor | 30w | 2005-04-04 | 2005-10-28 |  |  |  |  | 239d | 0d | start no earlier than 2005-04-04 | Barry; Steier; Scarvie; Mueller | 4800h |
| 325 | 1.10.5.3.1.2 | Evaluate modifcations to DCCT | 3w | 2005-10-31 | 2005-11-18 | 324 |  |  |  | 239d | 42d |  | Chin; Mueller; Steier | 360h |
| 326 | 1.10.5.3.1.3 | **EDI** | 65d | 2006-01-25 | 2006-04-25 | 325 |  |  |  | 197d |  |  |  |  |
| 327 | 1.10.5.3.1.3.1 | Produce Drawing Packages | 3w | 2006-01-25 | 2006-02-14 | 333 |  |  |  | 197d | 0d | start no earlier than 2005-11-02 |  |  |
| 328 | 1.10.5.3.1.3.2 | Place procurements and write job orders | 10w | 2006-02-15 | 2006-04-25 | 327 |  |  |  | 219d | 0d |  |  |  |
| 329 | 1.10.5.3.1.4 | Fabrication | 4w | 2006-04-26 | 2006-05-23 | 5, 328 |  |  |  | 219d | 0d |  |  |  |
| 330 | 1.10.5.3.1.5 | Installation and Testing | 4w | 2006-05-24 | 2006-06-20 | 329 |  |  |  | 219d | 74d |  |  |  |
| 331 | 1.10.5.3.2 | **Injection Energy Monitoring** | 100d | 2006-01-11 | 2006-05-30 |  |  |  |  | 162d |  |  |  |  |
| 332 | 1.10.5.3.2.1 | **EDI** | 60d | 2006-01-11 | 2006-04-04 |  |  |  |  | 162d |  |  |  |  |
| 333 | 1.10.5.3.2.1.1 | Produce Drawing Packages | 2w | 2006-01-11 | 2006-01-24 | 339 |  |  |  | 162d | 0d | start no earlier than 2005-11-02 |  |  |
| 334 | 1.10.5.3.2.1.2 | Place procurements and write job orders | 10w | 2006-01-25 | 2006-04-04 | 333 |  |  |  | 162d | 0d |  |  |  |
| 335 | 1.10.5.3.2.2 | Fabrication | 4w | 2006-04-05 | 2006-05-02 | 5, 334 |  |  |  | 234d | 0d |  |  |  |
| 336 | 1.10.5.3.2.3 | Installation and Testing | 4w | 2006-05-03 | 2006-05-30 | 335 |  |  |  | 234d | 89d |  |  |  |
| 337 | 1.10.5.3.3 | **Injection System Upgrades** | 204d | 2005-12-14 | 2006-10-02 |  |  |  |  | 145d |  |  |  |  |
| 338 | 1.10.5.3.3.1 | **EDI** | 65d | 2005-12-14 | 2006-03-21 |  |  |  |  | 162d | 0d |  |  |  |
| 339 | 1.10.5.3.3.1.1 | Produce Drawing Packages | 3w | 2005-12-14 | 2006-01-10 | 347 |  |  |  | 162d | 0d | start no earlier than 2005-11-02 |  |  |
| 340 | 1.10.5.3.3.1.2 | Place procurements and write job orders | 10w | 2006-01-11 | 2006-03-21 | 339 |  |  |  | 172d | 0d |  |  |  |
| 341 | 1.10.5.3.3.2 | EDI Update RSS Test Procedure | 3w | 2006-03-22 | 2006-04-11 | 340 |  |  |  | 268d | 123d | start no earlier than 2006-01-02 |  |  |
| 342 | 1.10.5.3.3.3 | Fabrication | 4w | 2006-03-22 | 2006-04-18 | 5, 338 |  |  |  | 243d | 98d |  |  |  |
| 343 | 1.10.5.3.3.4 | Installation and Testing | 4w | 2006-09-04 | 2006-09-29 | 342, 6 |  |  |  | 145d | 0d |  |  |  |
| 344 | 1.10.5.3.3.5 | 2 Day RSS Test (exclusive accelerator access) | 1d | 2006-10-02 | 2006-10-02 | 343, 341 |  |  |  | 145d | 16d |  |  |  |
| 345 | 1.10.5.3.4 | **Extraction Trigger Inhibit** | 208d | 2005-12-07 | 2006-09-29 |  |  |  |  | 146d |  |  |  | 880h |
| 346 | 1.10.5.3.4.1 | **EDI** | 55d | 2005-12-07 | 2006-02-28 |  |  |  |  | 162d |  |  | Mueller; Fahmie | 880h |
| 347 | 1.10.5.3.4.1.1 | Produce Drawing Packages | 1w | 2005-12-07 | 2005-12-13 | 163 |  |  |  | 167d | 0d | start no earlier than 2005-11-02 |  |  |
| 348 | 1.10.5.3.4.1.2 | Place procurements and write job orders | 10w | 2005-12-14 | 2006-02-28 | 347 |  |  |  | 187d | 0d |  |  |  |
| 349 | 1.10.5.3.4.2 | Fabrication | 2w | 2006-03-01 | 2006-03-14 | 5, 348 |  |  |  | 269d | 123d |  |  |  |
| 350 | 1.10.5.3.4.3 | Installation and Testing | 4w | 2006-09-04 | 2006-09-29 | 349, 6 |  |  |  | 146d | 17d |  |  |  |

| ID | WBS | Task | Type | Duration | Start | Finish | Predecessors | Complete | Remaining | Baseline start | Baseline finish | Baseline duration | Total slack | Free slack | Constraint | Resources | Work | Actual work |
| --- | --- | --- | --- | --- | --- | --- | --- | --- | --- | --- | --- | --- | --- | --- | --- | --- | --- | --- |
| 351 | 1.10.5.4 | **Beamline/Shutter Interlock** |  | 332d | 2005-03-21 A | 2006-07-04 |  | 7% | 307.41d | 2004-10-04 | 2004-10-04 | 1d | 209d |  |  |  | 560h | 16h |
| 352 | 1.10.5.4.1 | Evaluate Rad Monitors |  | 4w | 2005-03-21 A | 2005-04-15 A |  | 100% |  |  |  |  |  |  | start no earlier than 2005-03-21 |  |  |  |
| 353 | 1.10.5.4.2 | Procure Rad Monitors/Electronics |  | 4mo | 2005-10-03 | 2006-01-27 | 352 |  |  |  |  |  | 291d | 82d | start no earlier than 2005-10-03 |  |  |  |
| 354 | 1.10.5.4.3 | **EDI** |  | 70d | 2005-11-02 | 2006-02-14 | 352 |  |  |  |  |  | 162d |  |  | Mueller | 560h | 16h |
| 355 | 1.10.5.4.3.1 | Produce Drawing Packages |  | 4w | 2005-11-02 | 2005-11-29 |  |  |  |  |  |  | 167d | 0d | start no earlier than 2005-11-02 |  |  |  |
| 356 | 1.10.5.4.3.2 | Place procurements and write job orders |  | 10w | 2005-11-30 | 2006-02-14 | 355 |  |  |  |  |  | 197d | 0d |  |  |  |  |
| 357 | 1.10.5.4.4 | Fabrication |  | 14w | 2006-02-15 | 2006-05-23 | 5, 356 |  |  |  |  |  | 209d | 0d |  |  |  |  |
| 358 | 1.10.5.4.5 | Installation and Testing |  | 6w | 2006-05-24 | 2006-07-04 | 357, 353 |  |  |  |  |  | 209d | 64d |  |  |  |  |
| 359 | 1.10.5.5 | Interlock Review |  | 1d | 2006-02-15 | 2006-02-15 | 355, 347, 339, 333, 327, 163 |  |  |  |  |  | 197d | 10d |  |  |  |  |
| 360 | 1.10.5.6 | **Tracking Studies** |  | 355d | 2004-10-04 | 2006-02-17 |  |  |  |  |  |  | 215d |  |  |  | 2280h |  |
| 361 | 1.10.5.6.1 | Initial reverse studies (BL 2.1) |  | 12w | 2004-10-04 | 2004-12-24 |  |  |  |  |  |  | 345d | 0d |  | Nishimura | 480h |  |
| 362 | 1.10.5.6.2 | More detailed error scenarios |  | 12w | 2004-12-27 | 2005-03-18 | 361 |  |  |  |  |  | 345d | 120d |  | Nishimura | 480h |  |
| 363 | 1.10.5.6.3 | Initial forward studies (x.0/.1/.2/.3) |  | 4w | 2005-09-05 | 2005-09-30 | 362 |  |  |  |  |  | 225d | 10d | start no earlier than 2005-09-05 | Nishimura | 160h |  |
| 364 | 1.10.5.6.4 | Document assumptions |  | 3w | 2005-10-17 | 2005-11-04 | 363 |  |  |  |  |  | 215d | 0d | start no earlier than 2005-10-17 | Nishimura | 120h |  |
| 365 | 1.10.5.6.5 | Review results and determine final parameter range |  | 2w | 2005-11-07 | 2005-11-18 | 364 |  |  |  |  |  | 215d | 0d |  | Nishimura; Sannibale; Robin; Steier; Duarte; Donahue; Wan | 560h |  |
| 366 | 1.10.5.6.6 | Finalize initial and reverse studies |  | 4w | 2005-11-21 | 2005-12-16 | 365 |  |  |  |  |  | 215d | 0d |  | Nishimura | 160h |  |
| 367 | 1.10.5.6.7 | Independent second evaluation |  | 8w | 2005-12-19 | 2006-02-17 | 366 |  |  |  |  |  | 215d | 68d |  | Wan | 320h |  |
| 368 | 1.10.5.7 | Radiation Safety Review |  | 1d | 2006-03-30 | 2006-03-30 | 314, 359FS+4w, 321, 315, 297, 367 |  |  |  |  |  | 187d | 0d |  |  |  |  |
| 369 | 1.10.5.8 | Apply for DOE Approval for Second FSAD Change |  | 2w | 2006-03-31 | 2006-04-13 | 368 |  |  |  |  |  | 187d | 0d |  |  |  |  |
| 370 | 1.10.5.9 | Receive Approval | milestone | 0d | 2006-08-03 | 2006-08-03 | 369FS+16w |  |  |  |  |  | 187d | 42d |  |  |  |  |
| 372 | 1.10.6 | Storage Ring Radiation Protection Complete | milestone | 0d | 2006-10-02 | 2006-10-02 | 370, 358, 350, 344, 336, 330, 295 |  |  |  |  |  | 145d | 17d |  |  |  |  |
| 374 | 1.10.7 | **Diagnostics** |  | 385d | 2005-10-03 | 2007-03-30 |  |  |  |  |  |  | 16d |  |  |  | 120h |  |
| 375 | 1.10.7.1 | **Upgrade Cleaning System (Unapproved Scope)** |  | 10d | 2006-12-29 | 2007-01-12 | 7 |  |  |  |  |  | 71d |  |  |  |  |  |
| 376 | 1.10.7.1.1 | **Function Generator** |  | 10d | 2006-12-29 | 2007-01-12 |  |  |  |  |  |  | 71d |  |  |  |  |  |
| 377 | 1.10.7.1.1.1 | Receive Generator | milestone | 0d | 2006-12-29 | 2006-12-29 | 195FS+12w |  |  |  |  |  | 71d | 0d |  |  |  |  |
| 378 | 1.10.7.1.1.2 | Installation |  | 2w | 2007-01-01 | 2007-01-12 | 377 |  |  |  |  |  | 71d | 55d |  |  |  |  |

| ID | WBS | Task | Type | Duration | Start | Finish | Predecessors | Complete | Remaining | Baseline start | Baseline finish | Baseline duration | Total slack | Free slack | Constraint | Resources | Work | Actual work |
| --- | --- | --- | --- | --- | --- | --- | --- | --- | --- | --- | --- | --- | --- | --- | --- | --- | --- | --- |
| 379 | 1.10.7.2 | **Bunch by Bunch Current Monitor** |  | 55d | 2005-10-03 | 2005-12-16 |  |  |  |  |  |  | 346d |  |  |  | 120h |  |
| 380 | 1.10.7.2.1 | **Oscilloscope** |  | 55d | 2005-10-03 | 2005-12-16 | 5 |  |  |  |  |  | 346d |  |  |  | 120h |  |
| 381 | 1.10.7.2.1.1 | Specification and Order |  | 1w | 2005-10-03 | 2005-10-07 | 5 |  |  |  |  |  | 346d | 0d |  | Timossi; Barry; Sannibale | 120h |  |
| 382 | 1.10.7.2.1.2 | Receive Oscillioscope | milestone | 0d | 2005-12-02 | 2005-12-02 | 381FS+8w |  |  |  |  |  | 351d | 0d |  |  |  |  |
| 383 | 1.10.7.2.1.3 | Installation |  | 2w | 2005-12-05 | 2005-12-16 | 382 |  |  |  |  |  | 351d | 335d |  |  |  |  |
| 384 | 1.10.7.3 | **Visible Bunch Purity Monitor (Unapproved Scope)** |  | 130d | 2006-10-02 | 2007-03-30 | 7 |  |  |  |  |  | 16d |  |  |  |  |  |
| 385 | 1.10.7.3.1 | EDI |  | 8w | 2006-10-02 | 2006-11-24 | 5 |  |  |  |  |  | 16d | 0d |  |  |  |  |
| 386 | 1.10.7.3.2 | Component Procurement |  | 12w | 2006-11-27 | 2007-02-16 | 385 |  |  |  |  |  | 16d | 0d |  |  |  |  |
| 387 | 1.10.7.3.3 | Installation |  | 2w | 2007-02-19 | 2007-03-02 | 386, 391 |  |  |  |  |  | 16d | 0d |  |  |  |  |
| 388 | 1.10.7.3.4 | Commissioning |  | 4w | 2007-03-05 | 2007-03-30 | 387 |  |  |  |  |  | 16d | 0d |  |  |  |  |
| 389 | 1.10.7.3.5 | **X-Ray Option** |  | 50d | 2006-10-02 | 2006-12-08 |  |  |  |  |  |  | 66d |  |  |  |  |  |
| 390 | 1.10.7.3.5.1 | EDI |  | 2w | 2006-10-02 | 2006-10-13 | 5 |  |  |  |  |  | 66d | 0d |  |  |  |  |
| 391 | 1.10.7.3.5.2 | Material Procurement |  | 8w | 2006-10-16 | 2006-12-08 | 390 |  |  |  |  |  | 66d | 50d |  |  |  |  |
| 393 | 1.10.7.4 | Storage Ring Diagnostics Complete | milestone | 0d | 2007-03-30 | 2007-03-30 | 378, 383, 388 |  |  |  |  |  | 16d |  |  |  |  |  |
| 395 | 1.11 | **Controls and Timing** |  | 517d | 2005-03-25 A | 2007-03-26 |  | 15% | 438.89d | 2004-10-04 | 2004-10-04 | 1d | 20d |  |  |  | 1792h | 760h |
| 396 | 1.11.1 | User Gateing Signal |  | 20w | 2006-01-02 | 2006-05-19 |  |  |  | 2004-10-04 | 2004-10-04 | 1d | 241d | 90d | start no earlier than 2006-01-02 |  |  |  |
| 397 | 1.11.2 | Detail Timing Scheme |  | 6ew | 2006-01-24 | 2006-03-07 | 35 |  |  |  |  |  | 817.88d | 1.88d |  |  |  |  |
| 398 | 1.11.3 | Linac and Booster Timing |  | 20w | 2006-03-08 | 2006-07-25 | 397 |  |  | 2004-10-04 | 2004-10-04 | 1d | 194d | 43d | start no earlier than 2005-10-03 |  |  |  |
| 399 | 1.11.4 | **Power Supply Controls** |  | 335d | 2005-06-06 A | 2006-09-22 |  | 43% | 192.17d | 2004-10-04 | 2004-10-04 | 1d | 151d |  |  |  | 1352h | 760h |
| 400 | 1.11.4.1 | Network Infrastructure installed | milestone | 0d | 2006-03-01 | 2006-03-01 |  |  |  |  |  |  | 284d | 78d | start no earlier than 2006-03-01 |  |  |  |
| 401 | 1.11.4.2 | Develop PS test Procedure Document |  | 1w | 2006-05-22 | 2006-05-26 | 37 |  |  |  |  |  | 204d | 0d |  | Timossi; Jacobson; Williams | 120h |  |
| 402 | 1.11.4.3 | **Booster Large PS** |  | 322d | 2005-06-06 A | 2006-09-05 |  | 56% | 143.11d |  |  |  | 164d |  |  |  | 1072h | 640h |
| 403 | 1.11.4.3.1 | Develop Control Specs for Large Magnet Power Supplies |  | 8w | 2005-06-06 A | 2005-07-29 A |  | 100% |  |  |  |  |  |  | start no earlier than 2005-06-06 | Timossi; Williams | 640h | 640h |
| 404 | 1.11.4.3.2 | Develop Controls |  | 4w | 2006-05-29 | 2006-06-23 | 403, 401 |  |  |  |  |  | 204d | 0d |  | Williams; Timossi | 320h |  |
| 405 | 1.11.4.3.3 | Test Controls |  | 2w | 2006-06-26 | 2006-07-07 | 404, 400 |  |  |  |  |  | 204d | 40d |  | Williams | 80h |  |
| 406 | 1.11.4.3.4 | Final Test After Installation |  | 2d | 2006-09-04 | 2006-09-05 | 405, 6 |  |  |  |  |  | 164d |  |  | EM; Williams | 32h |  |

| ID | WBS | Task | Type | Duration | Start | Finish | Predecessors | Complete | Remaining | Total slack | Free slack | Constraint | Resources | Work | Actual work |
| --- | --- | --- | --- | --- | --- | --- | --- | --- | --- | --- | --- | --- | --- | --- | --- |
| 407 | 1.11.4.4 | **Booster Small PS** |  | 225d | 2005-11-07 | 2006-09-22 |  |  |  | 151d |  |  |  |  |  |
| 408 | 1.11.4.4.1 | Decide On mini-IOC or Compact PCI Controls | milestone | 0d | 2005-11-07 | 2005-11-07 |  |  |  | 349d | 0d | start no earlier than 2005-11-07 |  |  |  |
| 409 | 1.11.4.4.2 | Order IOC IO Boards Parts |  | 2d | 2005-11-07 | 2005-11-08 | 408, 416 |  |  | 349d | 0d |  |  |  |  |
| 410 | 1.11.4.4.3 | Receive, Fabricate & Test IOC IO Boards |  | 3w | 2005-11-09 | 2005-11-29 | 409 |  |  | 349d | 198d |  |  |  |  |
| 411 | 1.11.4.4.4 | ILC Removal and IOC Installation |  | 1w | 2006-09-04 | 2006-09-08 | 410, 6, 400 |  |  | 151d | 0d |  |  |  |  |
| 412 | 1.11.4.4.5 | PS IOC installation complete | milestone | 0d | 2006-09-08 | 2006-09-08 | 411 |  |  | 151d | 0d |  |  |  |  |
| 413 | 1.11.4.4.6 | Move ILC cabling to IOCs |  | 1w | 2006-09-11 | 2006-09-15 | 412 |  |  | 151d | 0d | start no earlier than 2006-04-03 |  |  |  |
| 414 | 1.11.4.4.7 | Final In Place Test |  | 1w | 2006-09-18 | 2006-09-22 | 413 |  |  | 151d |  |  |  |  |  |
| 415 | 1.11.4.5 | PS IOC control testing complete | milestone | 0d | 2006-09-22 | 2006-09-22 | 401, 413FS+1w |  |  | 151d | 0d |  |  |  |  |
| 416 | 1.11.4.6 | Spec and Design for Corrector Ramping System |  | 4w | 2005-10-03 A | 2005-10-28 | 4 | 75% | 1w | 349d | 5d | start no earlier than 2005-10-03 | Timossi | 160h | 120h |
| 417 | 1.11.5 | **BTS Diagnostics Controls** |  | 97d | 2005-10-03 | 2006-02-21 |  |  |  | 304d |  |  |  | 120h |  |
| 418 | 1.11.5.1 | **B1** |  | 5d | 2005-10-03 | 2005-10-07 |  |  |  | 396d |  |  |  | 80h |  |
| 419 | 1.11.5.1.1 | Rework Existing Frame Grabber Software |  | 1w | 2005-10-03 | 2005-10-07 | 5, 227 |  |  | 396d |  |  | Williams | 40h |  |
| 420 | 1.11.5.1.2 | Rework CRA |  | 1w | 2005-10-03 | 2005-10-07 | 5 |  |  | 396d |  |  | Williams | 40h |  |
| 421 | 1.11.5.2 | Beam Stopper Controls |  | 1w | 2006-02-15 | 2006-02-21 | 223 |  |  | 304d |  |  | Jacobson | 40h |  |
| 423 | 1.11.6 | **Storage Ring Collimator Controls** |  | 168d | 2005-03-25 A | 2005-11-15 |  | 96% | 6d | 369d |  |  |  |  |  |
| 424 | 1.11.6.1 | Motor Drive Avail for Software Test | milestone | 0d | 2005-03-25 A | 2005-03-25 A |  | 100% |  |  |  | start no earlier than 2005-03-25 |  |  |  |
| 425 | 1.11.6.2 | IOC Software Development |  | 3w | 2005-03-25 A | 2005-04-14 A | 424 | 100% |  |  |  |  |  |  |  |
| 426 | 1.11.6.3 | Order Boards and Crate |  | 1d | 2005-04-15 A | 2005-04-15 A | 425 | 100% |  |  |  |  |  |  |  |
| 427 | 1.11.6.4 | Local Conrtol Test |  | 2w | 2005-04-18 A | 2005-04-29 A | 311, 426 | 100% |  |  |  |  |  |  |  |
| 428 | 1.11.6.5 | Install IOC |  | 1d | 2005-05-02 A | 2005-05-02 A | 427 | 100% |  |  |  |  |  |  |  |
| 429 | 1.11.6.6 | Install Second IOC |  | 1d | 2005-11-15 | 2005-11-15 | 428 |  |  | 374d |  | start no earlier than 2005-11-15 |  |  |  |
| 430 | 1.11.7 | **BTS Collimator Controls** |  | 6d | 2006-01-16 | 2006-01-23 |  |  |  | 325d |  |  |  | 40h |  |
| 431 | 1.11.7.1 | IOC Software Configuration |  | 3d | 2006-01-16 | 2006-01-18 | 303FS+2w |  |  | 325d | 0d |  | Steele | 24h |  |
| 432 | 1.11.7.2 | Order Boards and Crate |  | 1d | 2006-01-19 | 2006-01-19 | 431 |  |  | 325d | 0d |  |  |  |  |
| 433 | 1.11.7.3 | Test Configuration |  | 1d | 2006-01-20 | 2006-01-20 | 432 |  |  | 325d | 0d |  | Steele | 8h |  |
| 434 | 1.11.7.4 | Install IOC |  | 1d | 2006-01-23 | 2006-01-23 | 433 |  |  | 325d |  |  | EI | 8h |  |

| ID | WBS | Task | Type | Duration | Start | Finish | Predecessors | Complete | Remaining | Baseline start | Baseline finish | Baseline duration | Total slack | Free slack | Constraint | Resources | Work | Actual work |
| --- | --- | --- | --- | --- | --- | --- | --- | --- | --- | --- | --- | --- | --- | --- | --- | --- | --- | --- |
| 435 | 1.11.8 | **Bunch Cleaning Controls(Unapproved Scope)** |  | 126d | 2006-10-02 | 2007-03-26 | 7 |  |  |  |  |  | 0d |  |  |  |  |  |
| 436 | 1.11.8.1 | **Booster Scraper Controls** |  | 106d | 2006-10-02 | 2007-02-26 |  |  |  |  |  |  | 0d |  |  |  |  |  |
| 437 | 1.11.8.1.1 | Collimator Controls Spec |  | 5d | 2006-10-02 | 2006-10-06 | 5 |  |  |  |  |  | 0d |  | start no earlier than 2004-12-06 |  |  |  |
| 438 | 1.11.8.1.2 | IOC Software Development |  | 3w | 2006-10-09 | 2006-10-27 | 437 |  |  |  |  |  | 74d | 0d |  |  |  |  |
| 439 | 1.11.8.1.3 | Order Boards and Crate |  | 1d | 2006-10-30 | 2006-10-30 | 438 |  |  |  |  |  | 74d |  |  |  |  |  |
| 440 | 1.11.8.1.4 | Local Conrtol Test |  | 2w | 2007-02-12 | 2007-02-23 | 439, 185 |  |  |  |  |  | 0d |  |  |  |  |  |
| 441 | 1.11.8.1.5 | Install IOC |  | 1d | 2007-02-26 | 2007-02-26 | 440 |  |  |  |  |  | 0d |  |  |  |  |  |
| 442 | 1.11.8.2 | **Function Generator Controls** |  | 16d | 2006-10-02 | 2006-10-23 |  |  |  |  |  |  | 90d |  |  |  |  |  |
| 443 | 1.11.8.2.1 | Develop GPBI Control |  | 2w | 2006-10-02 | 2006-10-13 | 5 |  |  |  |  |  | 90d | 0d |  |  |  |  |
| 444 | 1.11.8.2.2 | Instrument Test |  | 1w | 2006-10-16 | 2006-10-20 | 443 |  |  |  |  |  | 90d | 0d |  |  |  |  |
| 445 | 1.11.8.2.3 | Install GPIB IOC |  | 1d | 2006-10-23 | 2006-10-23 | 444 |  |  |  |  |  | 90d |  |  |  |  |  |
| 446 | 1.11.8.3 | Control Room Application |  | 4w | 2007-02-27 | 2007-03-26 | 441, 445 |  |  |  |  |  | 0d |  |  |  |  |  |
| 447 | 1.11.9 | **RF Controls** |  | 319.94d | 2005-06-01 A | 2006-08-29 |  | 21% | 251.38d | 2004-10-04 | 2004-10-04 | 1d | 169.06d |  |  |  | 280h |  |
| 448 | 1.11.9.1 | Develop Control Specs for RF Transmitter |  | 15d | 2005-06-01 A | 2005-06-21 A |  | 100% |  |  |  |  |  |  | start no earlier than 2005-06-01 |  |  |  |
| 449 | 1.11.9.2 | Transmitter Procurement Ramping System Layout Complete | milestone | 0d | 2005-06-21 A | 2005-06-21 A | 448 | 100% |  |  |  |  |  |  |  |  |  |  |
| 450 | 1.11.9.3 | Control System Specification complete for Manufacturer of RF transmitter CS interface (Embedded PLC) | milestone | 0d | 2005-06-21 A | 2005-06-21 A | 449 | 100% |  |  |  |  |  |  |  |  |  |  |
| 451 | 1.11.9.4 | Specification and design for RF ramping system |  | 4w | 2005-10-31 | 2005-11-25 | 450 |  |  |  |  |  | 336d | 0d | start no earlier than 2005-10-31 |  |  |  |
| 452 | 1.11.9.5 | Specification for LBNL Part of RF transmitter CS interface (Embedded PLC) |  | 4w | 2005-11-28 | 2005-12-23 | 451 |  |  |  |  |  | 336d | 111.94d |  |  |  |  |
| 453 | 1.11.9.6 | Develop Transmitter Controls |  | 2w | 2006-05-30 | 2006-06-13 | 449, 131, 452 |  |  |  |  |  | 224.06d | 73.06d |  | Timossi; Williams; Urashka | 240h |  |
| 454 | 1.11.9.7 | Develop Interlock Controls |  | 1w | 2006-08-22 | 2006-08-29 | 152 |  |  |  |  |  | 134.06d | 18.06d |  | EC | 40h |  |
| 456 | 1.11.10 | Controls and Timing Complete | milestone | 0d | 2006-09-22 | 2006-09-22 | 453, 428, 415, 396, 398, 454 |  |  |  |  |  | 151d | 23d |  |  |  |  |
| 458 | 1.12 | **Accelerator Physics Studies/Commissioning** |  | 340d | 2004-11-22 A | 2006-03-17 |  | 3% | 328.9d |  |  |  | 286d |  |  |  | 47532h | 600h |
| 459 | 1.12.1 | **Precommissioning Studies** |  | 340d | 2004-11-22 A | 2006-03-17 |  | 3% | 328.9d |  |  |  | 286d |  |  |  | 47532h | 600h |
| 460 | 1.12.1.1 | **Injector transfer efficiencies** |  | 261d | 2004-11-22 A | 2005-11-22 |  | 4% | 251.43d |  |  |  | 365d |  |  |  | 43500h | 600h |
| 461 | 1.12.1.1.1 | Linac beam loading and beam quality |  | 172ed | 2004-11-22 | 2005-05-13 |  |  |  |  |  |  | 2007d | 275d | start no earlier than 2004-11-22 | Nishimura; Kwiatkowski; Byrne | 6480h |  |
| 462 | 1.12.1.1.2 | Booster injection efficiency |  | 120ed | 2005-03-06 | 2005-07-04 |  |  |  |  |  |  | 1851d | 119d | start no earlier than 2005-03-06 | Nishimura; Kwiatkowski; Byrne | 8640h |  |
| 463 | 1.12.1.1.3 | Booster extraction efficiency |  | 90ed | 2005-04-03 A | 2005-07-02 |  | 10% | 81ed |  |  |  | 1857d | 125d | start no earlier than 2005-04-03 | Nishimura; Byrne | 3132h | 216h |
| 464 | 1.12.1.1.4 | Storage ring injection efficiency/alignment/steering |  | 160ed | 2005-03-06 A | 2005-08-13 |  | 10% | 144ed |  |  |  | 1732d | 0d | start no earlier than 2005-03-06 | Byrne; Steier; Robin | 8448h | 384h |
| 465 | 1.12.1.1.5 | Learn how to use existing booster BPM's |  | 20ew | 2005-07-05 | 2005-11-22 |  |  |  |  |  |  | 1552.12d |  | start no earlier than 2005-07-05 | Sannibale; Timossi; Chin; Byrne; Nishimura | 16800h |  |
| 466 | 1.12.1.2 | Test ways to use existing kickers for tune measurement in booster |  | 12ew | 2005-12-23 | 2006-03-17 | 209 |  |  |  |  |  | 1206d |  |  | Barry; Sannibale | 4032h |  |
| 467 | 1.12.1.3 | Precommissioning Studies Complete | milestone | 0d | 2005-08-13 | 2005-08-13 | 461, 462, 463, 464 |  |  |  |  |  | 411d | 303d |  |  |  |  |
| 469 | 1.13 | Ready for Commisioning and Start Up of Full Energy Injector | milestone | 0d | 2006-10-11 | 2006-10-11 | 467, 75, 105, 168, 264, 289 |  |  |  |  |  | 108d | 0d |  |  |  |  |
| 471 | 1.14 | Commissioning/Startup |  | 14ed | 2006-10-11 | 2006-10-25 | 469 |  |  |  |  |  | 457.88d | 0d |  |  |  |  |
| 473 | 1.15 | Ready for Top Off Comissioning | milestone | 0d | 2006-10-25 | 2006-10-25 | 471, 456, 372 |  |  |  |  |  | 128d |  |  |  |  |  |
| 475 | 1.16 | Commisioning of Cleaning System |  | 4w | 2007-03-27 | 2007-04-23 | 198, 471 |  |  |  |  |  | 0d |  |  |  |  |  |
